# modular PLASC

Schedule from MS Project, 2012-02-10 to 2013-05-02.
National Assembly for Wales

## Calendars

- Standard: Mon-Fri 08:00-12:00, 13:00-17:00; Sat-Sun off.

## Resources

| Resource |
| --- |
| AM |
| LL |
| MM |
| MP |
| JH |
| LO |
| CP |
| MS |
| SF |
| TG |
| GH |

## Schedule

| ID | WBS | Task | Type | Duration | Start | Finish | Predecessors | Total slack | Free slack | Constraint | Deadline |
| --- | --- | --- | --- | --- | --- | --- | --- | --- | --- | --- | --- |
| 2 | 1 | NDC 2012 Guidance Notes Released |  | 1d | 2012-04-09 | 2012-04-09 |  | 192d |  | start no earlier than 2012-04-09 |  |
| 4 | 2 | Attendance Secondary 2012 Guidance Notes Released |  | 1d | 2012-04-25 | 2012-04-25 |  | 180d |  | start no earlier than 2012-04-25 |  |
| 6 | 3 | **WED 2012 on DEWi** |  | 22d | 2012-04-16 | 2012-05-15 |  | 252d |  |  |  |
| 7 | 3.1 | WED 2012 DEWi development |  | 10d | 2012-04-16 | 2012-04-27 |  | 252d | 0d | start no earlier than 2012-04-16 |  |
| 8 | 3.2 | WED 2012 DEWi UAT |  | 5d | 2012-04-30 | 2012-05-04 | 7 | 252d | 0d | start no earlier than 2009-03-30 |  |
| 9 | 3.3 | WED 2012 DEWi rework |  | 3d | 2012-05-07 | 2012-05-09 | 8 | 252d | 0d | start no earlier than 2009-04-06 |  |
| 10 | 3.4 | WED 2012 Release to test DEWi site | milestone | 1d | 2012-05-10 | 2012-05-10 | 9 | 252d | 0d |  |  |
| 11 | 3.5 | WED 2012 DEWi UAT on test site |  | 2d | 2012-05-11 | 2012-05-14 | 10 | 252d | 0d |  |  |
| 12 | 3.6 | WED 2012 Release to live DEWi site | milestone | 1d | 2012-05-15 | 2012-05-15 | 11 | 252d |  | start no earlier than 2009-08-03 |  |
| 15 | 4 | **Spring SDF meetings** |  | 21d | 2012-02-16 | 2012-03-15 |  | 0d |  |  |  |
| 16 | 4.1 | Software Development Forum meeting | milestone | 1d | 2012-02-16 | 2012-02-16 |  | 0d |  | start no earlier than 2012-02-16 | 2012-02-16 |
| 17 | 4.2 | Spec review period: PLASC, EOTAS & Attendance 2013 |  | 16d | 2012-02-17 | 2012-03-09 | 16 | 298d | 3d | finish no earlier than 2011-03-02 |  |
| 18 | 4.3 | Software Development Forum meeting | milestone | 1d | 2012-03-15 | 2012-03-15 | 17 | 295d |  | start no earlier than 2012-03-15 |  |
| 20 | 5 | **CBDS (standard) change cycle** |  | 1d | 2012-04-02 | 2012-04-02 |  | 283d |  |  |  |
| 21 | 5.1 | CBDS 1213 published | milestone | 1d | 2012-04-02 | 2012-04-02 |  | 283d |  | start no earlier than 2012-04-02 |  |
| 22 | 5.2 | Publish 1213 Learning Activity codeset (look-up) | milestone | 1d | 2012-04-02 | 2012-04-02 |  | 283d |  | start no earlier than 2012-04-02 |  |
| 23 | 5.3 | Publish 1213 Learning Activity Provider codeset (look-up) | milestone | 1d | 2012-04-02 | 2012-04-02 |  | 283d |  | start no earlier than 2012-04-02 |  |
| 24 | 6 | **Develop January PLASC and EOTAS 2013** |  | 102d | 2012-02-10 | 2012-07-02 |  | 218d |  |  |  |
| 25 | 6.1 | **Specification** |  | 21d | 2012-02-10 | 2012-03-09 |  | 299d |  |  |  |
| 26 | 6.1.1 | Draft specification release | milestone | 1d | 2012-02-10 | 2012-02-10 |  | 319d |  | start no earlier than 2012-02-10 |  |
| 27 | 6.1.2 | Supplier review period |  | 16d | 2012-02-13 | 2012-03-05 |  | 303d |  | start no earlier than 2012-02-13 |  |
| 28 | 6.1.3 | Version 1 specification release | milestone | 1d | 2012-03-09 | 2012-03-09 |  | 299d |  | start no earlier than 2012-03-09 |  |
| 29 | 6.2 | **xslt development** |  | 18d | 2012-06-04 | 2012-06-27 |  | 221d |  |  |  |
| 30 | 6.2.1 | Draft fileset release | milestone | 1d | 2012-06-04 | 2012-06-04 |  | 226d | 0d | start no earlier than 2012-06-04 |  |
| 31 | 6.2.2 | Supplier review period |  | 11d | 2012-06-05 | 2012-06-19 | 30 | 226d | 5d |  |  |
| 32 | 6.2.3 | Final fileset release | milestone | 1d | 2012-06-27 | 2012-06-27 | 31 | 221d |  | start no earlier than 2012-06-27 |  |

Notes:
- 17: Consider January PLASC 2011, Post-16 Summer PLASC 2011 and Attendance 2011 specifications
- 25: Publication in the same bundle as Post-16 Summer PLASC 2011 and Attendance Collections 2011

| ID | WBS | Task | Type | Duration | Start | Finish | Predecessors | Total slack | Free slack | Constraint |
| --- | --- | --- | --- | --- | --- | --- | --- | --- | --- | --- |
| 33 | 6.3 | **DEWi developments** |  | 1d | 2012-07-02 | 2012-07-02 |  | 218d |  |  |
| 34 | 6.3.1 | Release to supplier test DEWi sites for PLASC & EOTAS 2013 | milestone | 1d | 2012-07-02 | 2012-07-02 |  | 218d |  | start no earlier than 2012-07-02 |
| 36 | 7 | **January PLASC & EOTAS 2013 xslt and DEWi development** |  | 188d | 2012-04-16 | 2013-01-02 |  | 86d |  |  |
| 37 | 7.1 | Jan & EOTAS 2013 xslt & DEWi development |  | 25d | 2012-04-16 | 2012-05-18 |  | 229d | 1d | start no earlier than 2012-04-16 |
| 38 | 7.2 | Jan & EOTAS 2013 xslt UAT |  | 9d | 2012-05-22 | 2012-06-01 | 37 | 228d | 0d | start no earlier than 2012-05-22 |
| 39 | 7.3 | Jan & EOTAS 2013 xslt draft fileset release | milestone | 1d | 2012-06-04 | 2012-06-04 | 38 | 238d |  | start no earlier than 2012-06-04 |
| 40 | 7.4 | Jan & EOTAS 2013 DEWi UAT |  | 8d | 2012-06-04 | 2012-06-13 | 38 | 228d | 7d | start no earlier than 2012-06-04 |
| 41 | 7.5 | Jan & EOTAS 2013 xslt supplier review period |  | 11d | 2012-06-05 | 2012-06-19 |  | 227d |  | start no earlier than 2012-06-05 |
| 42 | 7.6 | Jan & EOTAS 2013 xslt rework |  | 3d | 2012-06-20 | 2012-06-22 |  | 217d | 0d | start no earlier than 2012-06-20 |
| 43 | 7.7 | Jan & EOTAS 2013 xslt rework UAT |  | 2d | 2012-06-25 | 2012-06-26 | 42 | 217d | 0d | start no earlier than 2008-12-11 |
| 44 | 7.8 | Jan & EOTAS 2013 DEWi rework |  | 3d | 2012-06-25 | 2012-06-27 | 40, 42 | 221d |  | start no earlier than 2012-06-14 |
| 45 | 7.9 | Jan & EOTAS 2013 xslt final fileset release |  | 1d | 2012-06-27 | 2012-06-27 | 43 | 221d |  | start no earlier than 2012-06-27 |
| 46 | 7.10 | Jan & EOTAS 2013 Release to test DEWi site | milestone | 1d | 2012-06-27 | 2012-06-27 | 43 | 217d | 0d | start no earlier than 2012-06-27 |
| 47 | 7.11 | Jan & EOTAS 2013 DEWi UAT on test site |  | 3d | 2012-06-28 | 2012-07-02 | 46 | 217d | 0d | start no earlier than 2009-07-08 |
| 48 | 7.12 | Jan & EOTAS 2013 Release to supplier test DEWi site | milestone | 1d | 2012-07-03 | 2012-07-03 | 47 | 217d |  | start no earlier than 2009-07-14 |
| 49 | 7.13 | Jan & EOTAS 2013 Release to live DEWi site | milestone | 1d | 2013-01-02 | 2013-01-02 | 47 | 86d |  | start no earlier than 2013-01-02 |
| 52 | 8 | Post-16 PLASC 2012 Guidance Notes Released |  | 1d | 2012-08-24 | 2012-08-24 |  | 179d |  | start no earlier than 2012-08-24 |
| 55 | 9 | **Develop Attendance 2013** |  | 167d | 2012-02-10 | 2012-10-01 |  | 153d |  |  |
| 56 | 9.1 | **Specification** |  | 21d | 2012-02-10 | 2012-03-09 |  | 299d |  |  |
| 57 | 9.1.1 | Draft specification release | milestone | 1d | 2012-02-10 | 2012-02-10 |  | 319d |  | start no earlier than 2012-02-10 |
| 58 | 9.1.2 | Supplier review period |  | 16d | 2012-02-13 | 2012-03-05 |  | 303d |  | start no earlier than 2012-02-13 |
| 59 | 9.1.3 | Version 1 specification release | milestone | 1d | 2012-03-09 | 2012-03-09 |  | 299d |  | start no earlier than 2012-03-09 |
| 60 | 9.2 | **xslt development** |  | 18d | 2012-09-03 | 2012-09-26 |  | 156d |  |  |
| 61 | 9.2.1 | Draft fileset release | milestone | 1d | 2012-09-03 | 2012-09-03 |  | 161d | 0d | start no earlier than 2012-09-03 |
| 62 | 9.2.2 | Supplier review period |  | 11d | 2012-09-04 | 2012-09-18 | 61 | 161d | 5d | start no earlier than 2010-09-07 |
| 63 | 9.2.3 | Final fileset release | milestone | 1d | 2012-09-26 | 2012-09-26 | 62 | 156d |  | start no earlier than 2012-09-26 |

Notes:
- 44: Including released learning activity and provider codeset look-ups on 1/4/10
- 56: Publication in the same bundle as January PLASC 2012
- 60: Development in the same bundle as NDC 2012

| ID | WBS | Task | Type | Duration | Start | Finish | Predecessors | Total slack | Free slack | Constraint |
| --- | --- | --- | --- | --- | --- | --- | --- | --- | --- | --- |
| 64 | 9.3 | **DEWi developments** |  | 1d | 2012-10-01 | 2012-10-01 |  | 153d |  |  |
| 65 | 9.3.1 | Release to supplier test DEWi sites for Attendance & NDC 2013 | milestone | 1d | 2012-10-01 | 2012-10-01 |  | 153d |  | start no earlier than 2012-10-01 |
| 67 | 10 | Attendance Primary 2012 Guidance Notes Released |  | 1d | 2012-06-29 | 2012-06-29 |  | 219d |  | start no earlier than 2012-06-29 |
| 69 | 11 | **Summer Attendance & NDC 2013 xslt and DEWi development** |  | 199d | 2012-07-30 | 2013-05-02 |  | 0d |  |  |
| 70 | 11.1 | Summer 2013 xslt and DEWi development |  | 20d | 2012-07-30 | 2012-08-24 |  | 151d | 0d | start no earlier than 2012-07-30 |
| 71 | 11.2 | Summer 2013 xslt UAT |  | 5d | 2012-08-27 | 2012-08-31 | 70 | 151d | 0d | start no earlier than 2009-05-25 |
| 72 | 11.3 | Summer 2013 xslt draft fileset release | milestone | 1d | 2012-09-03 | 2012-09-03 | 71 | 151d | 0d | start no earlier than 2010-09-06 |
| 73 | 11.4 | Summer 2013 xslt supplier review period |  | 11d | 2012-09-04 | 2012-09-18 | 72 | 151d | 0d |  |
| 74 | 11.5 | Summer 2013 DEWi UAT |  | 5d | 2012-09-03 | 2012-09-07 | 71 | 163d | 7d |  |
| 75 | 11.6 | Summer 2013 xslt rework |  | 4d | 2012-09-19 | 2012-09-24 | 73 | 151d | 0d | finish no earlier than 2011-09-21 |
| 76 | 11.7 | Summer 2013 xslt rework UAT |  | 2d | 2012-09-25 | 2012-09-26 | 75 | 151d | 0d | start no earlier than 2008-12-11 |
| 77 | 11.8 | Summer 2013 DEWi rework |  | 5d | 2012-09-19 | 2012-09-25 | 73, 74 | 156d | 0d | start no earlier than 2012-09-13 |
| 78 | 11.9 | Summer 2013 Release to test DEWi site for NDC & Attendance collections 2013 |  | 1d | 2012-09-26 | 2012-09-26 | 77 | 156d |  | start no earlier than 2009-10-02 |
| 79 | 11.10 | Summer 2013 xslt final fileset release | milestone | 1d | 2012-09-27 | 2012-09-27 | 76 | 151d | 0d | start no earlier than 2012-09-26 |
| 80 | 11.11 | Summer 2013 DEWi UAT on test site |  | 3d | 2012-09-28 | 2012-10-02 | 79 | 151d | 0d |  |
| 81 | 11.12 | Summer 2013 Release to supplier test DEWi site for NDC & Attendance collections 2013 | milestone | 1d | 2012-10-03 | 2012-10-03 | 80 | 151d |  | start no earlier than 2011-10-03 |
| 82 | 11.13 | Summer 2013 Release to live DEWi site for NDC & Attendance collections 2013 | milestone | 1d | 2013-05-02 | 2013-05-02 | 80 | 0d |  | start no earlier than 2013-05-02 |
| 84 | 12 | **Summer SDF meeting** |  | 17d | 2012-06-07 | 2012-06-29 |  | 219d |  |  |
| 85 | 12.1 | Software Development Forum meeting | milestone | 1d | 2012-06-07 | 2012-06-07 |  | 219d | 0d | start no earlier than 2012-06-07 |
| 86 | 12.2 | Spec review period |  | 16d | 2012-06-08 | 2012-06-29 | 85 | 219d |  | start no earlier than 2009-10-07 |
| 87 | 13 | **Develop NDC 2013** |  | 87d | 2012-06-01 | 2012-10-01 |  | 153d |  |  |
| 88 | 13.1 | **Specification** |  | 19d | 2012-06-01 | 2012-06-27 |  | 221d |  |  |
| 89 | 13.1.1 | Draft specification release | milestone | 1d | 2012-06-01 | 2012-06-01 |  | 222d | 0d | start no earlier than 2012-06-01 |
| 90 | 13.1.2 | Supplier review period |  | 16d | 2012-06-04 | 2012-06-25 | 89 | 222d | 1d | start no earlier than 2011-06-08 |
| 91 | 13.1.3 | Version 1 specification release | milestone | 1d | 2012-06-27 | 2012-06-27 | 90 | 221d |  | start no earlier than 2012-06-27 |

Notes:
- 64: Development in the same bundle as NDC 2012
- 69: Summer Post-16 PLASC, Attendance and NDC 2012
- 86: Consider Post-16 September PLASC 2012 specification

| ID | WBS | Task | Type | Duration | Start | Finish | Predecessors | Total slack | Free slack | Constraint |
| --- | --- | --- | --- | --- | --- | --- | --- | --- | --- | --- |
| 92 | 13.2 | **xslt development** |  | 19d | 2012-09-03 | 2012-09-27 |  | 155d |  |  |
| 93 | 13.2.1 | Draft fileset release | milestone | 1d | 2012-09-03 | 2012-09-03 |  | 161d | 0d | start no earlier than 2012-09-03 |
| 94 | 13.2.2 | Supplier review period |  | 11d | 2012-09-04 | 2012-09-18 | 93 | 161d | 6d | start no earlier than 2008-09-16 |
| 95 | 13.2.3 | Final fileset release | milestone | 1d | 2012-09-27 | 2012-09-27 | 94 | 155d |  | start no earlier than 2012-09-27 |
| 96 | 13.3 | **DEWi developments** |  | 1d | 2012-10-01 | 2012-10-01 |  | 153d |  |  |
| 97 | 13.3.1 | Release to supplier test DEWi sites for Attendance & NDC 2013 | milestone | 1d | 2012-10-01 | 2012-10-01 |  | 153d |  | start no earlier than 2012-10-01 |
| 99 | 14 | **Autumn SDF meetings** |  | 21d | 2012-10-09 | 2012-11-06 |  | 127d |  |  |
| 100 | 14.1 | Software Development Forum meeting | milestone | 1d | 2012-10-09 | 2012-10-09 |  | 130d | 0d | start no earlier than 2012-10-09 |
| 101 | 14.2 | Spec review period |  | 16d | 2012-10-10 | 2012-10-31 | 100 | 130d | 3d | start no earlier than 2009-10-07 |
| 102 | 14.3 | Software Development Forum meeting | milestone | 1d | 2012-11-06 | 2012-11-06 | 101 | 127d |  | start no earlier than 2012-11-06 |
| 104 | 15 | **Develop Post-16 September PLASC 2013** |  | 136d | 2012-10-04 | 2013-04-11 |  | 15d |  |  |
| 105 | 15.1 | **Specification** |  | 21d | 2012-10-04 | 2012-11-01 |  | 130d |  |  |
| 106 | 15.1.1 | Draft specification release | milestone | 1d | 2012-10-04 | 2012-10-04 |  | 134d | 0d | start no earlier than 2012-10-04 |
| 107 | 15.1.2 | Supplier review period |  | 16d | 2012-10-05 | 2012-10-26 | 106 | 134d |  | start no earlier than 2011-10-12 |
| 108 | 15.1.3 | Version 1 specification release | milestone | 1d | 2012-11-01 | 2012-11-01 |  | 130d |  | start no earlier than 2012-11-01 |
| 109 | 15.2 | **xslt development** |  | 103d | 2012-11-20 | 2013-04-11 |  | 15d |  |  |
| 110 | 15.2.1 | Draft fileset release | milestone | 1d | 2012-11-20 | 2012-11-20 |  | 105d | 0d | start no earlier than 2012-11-20 |
| 111 | 15.2.2 | Supplier review period |  | 11d | 2012-11-21 | 2012-12-05 | 110 | 105d | 5d |  |
| 112 | 15.2.3 | Final fileset release | milestone | 1d | 2012-12-13 | 2012-12-13 | 111 | 100d |  | start no earlier than 2012-12-13 |
| 113 | 15.2.4 | Update of fileset release with 13/14 look-ups |  | 1d | 2013-04-11 | 2013-04-11 |  | 15d |  | start no earlier than 2013-04-11 |
| 114 | 15.3 | **DEWi developments** |  | 82d | 2012-12-13 | 2013-04-05 |  | 19d |  |  |
| 115 | 15.3.1 | Release to supplier test DEWi sites for Post-16 September PLASC 2013 | milestone | 1d | 2012-12-13 | 2012-12-13 |  | 100d |  | start no earlier than 2012-12-13 |
| 116 | 15.3.2 | Release update with look-ups to supplier test DEWi site Post-16 September PLASC 2013 |  | 1d | 2013-04-05 | 2013-04-05 |  | 19d |  | start no earlier than 2013-04-05 |
| 117 | 16 | **Post-16 Sept 2013 xslt and DEWi development** |  | 115d | 2012-11-01 | 2013-04-10 |  | 16d |  |  |
| 118 | 16.1 | Sept 2013 xslt and DEWi development |  | 10d | 2012-11-01 | 2012-11-14 |  | 92d | 0d | start no earlier than 2012-11-01 |
| 119 | 16.2 | Sept 2013 xslt UAT |  | 3d | 2012-11-15 | 2012-11-19 | 118 | 92d | 0d | start no earlier than 2009-11-16 |
| 120 | 16.3 | Sept 2013 xslt draft fileset release | milestone | 1d | 2012-11-20 | 2012-11-20 | 119 | 92d | 0d | start no earlier than 2009-11-23 |
| 121 | 16.4 | Sept 2013 xslt supplier review period |  | 11d | 2012-11-21 | 2012-12-05 | 120 | 92d | 0d |  |
| 122 | 16.5 | September 2013 DEWi UAT |  | 3d | 2012-11-20 | 2012-11-22 | 119 | 105d | 9d |  |
| 123 | 16.6 | Sept 2013 xslt rework |  | 3d | 2012-12-06 | 2012-12-10 | 121 | 92d | 0d |  |
| 124 | 16.7 | Sept 2013 xslt rework UAT |  | 2d | 2012-12-11 | 2012-12-12 | 123 | 92d | 0d |  |
| 125 | 16.8 | September 2013 DEWi rework |  | 5d | 2012-12-06 | 2012-12-12 | 121, 122 | 96d | 0d |  |
| 126 | 16.9 | September 2013 Release to test DEWi site |  | 1d | 2012-12-13 | 2012-12-13 | 125 | 96d | 0d |  |
| 127 | 16.10 | Sept 2013 xslt final fileset release | milestone | 1d | 2012-12-13 | 2012-12-13 | 124 | 92d | 76d | start no earlier than 2011-12-12 |
| 128 | 16.11 | September 2013 DEWi UAT on test site |  | 3d | 2012-12-14 | 2012-12-18 | 126 | 96d | 0d |  |
| 129 | 16.12 | September 2013 Release to supplier test DEWi site | milestone | 1d | 2012-12-19 | 2012-12-19 | 128 | 96d |  | start no earlier than 2009-12-21 |
| 130 | 16.13 | Sept 2013 xslt and DEWi inclusion of 13/14 look-ups |  | 4d | 2013-04-01 | 2013-04-04 | 127 | 16d | 0d | start no earlier than 2013-04-01 |
| 131 | 16.14 | Sept 2013 xslt and DEWi UAT on 13/14 look-ups update |  | 3d | 2013-04-05 | 2013-04-09 | 130 | 16d | 0d |  |
| 132 | 16.15 | Sept 2013 xslt update release | milestone | 1d | 2013-04-10 | 2013-04-10 | 131 | 16d |  | start no earlier than 2010-04-15 |
| 133 | 16.16 | September 2013 Release to live DEWi site | milestone | 1d | 2013-04-10 | 2013-04-10 | 131 | 16d |  | start no earlier than 2010-09-16 |
| 135 | 17 | Jan PLASC & EOTAS 2013 Guidance Notes Released |  | 1d | 2012-12-10 | 2012-12-10 |  | 103d |  | start no earlier than 2012-12-10 |

Notes:
- 92: Development in the same bundle as Post-16 Summer PLASC 2010 and Attendance Collections 2010
- 96: Development in the same bundle as Post-16 Summer PLASC 2010 and Attendance Collections 2010
- 101: Consider Post-16 September PLASC 2010 specification
